# 发票管理平台V1.0-WBS

Schedule from MS Project, 2017-09-01 to 2017-11-10, costs in ¥, A marks actual dates.

## Calendars

- 标准: Mon-Fri 08:00-12:00, 13:00-17:00; Sat-Sun off. Exceptions (off unless hours are given): 2017-10-01 to 2017-10-08.

## Resources

| Resource | Rate |
| --- | --- |
| 客户代表 |  |
| 胡威 | 50 |
| 屈文敏 | 50 |
| 唐锦涛 | 50 |
| 项目组 | 300 |
| 评审组 | 200 |
| 邓毅伟 | 50 |
| 周巨 | 50 |
| 郑康怡 | 50 |
| 蔡杰 | 50 |
| 用户代表 |  |

## Schedule

| ID | WBS | Task | Type | Duration | Start | Finish | Complete | Baseline start | Baseline finish | Baseline duration | Resources | Work | Actual work | Cost | Baseline cost | Actual cost |
| --- | --- | --- | --- | --- | --- | --- | --- | --- | --- | --- | --- | --- | --- | --- | --- | --- |
| 1 | 1 | **项目立项** |  | 1d | 2017-09-01 A | 2017-09-01 A | 100% | 2017-09-01 | 2017-09-01 | 1d |  | 8h | 8h | 400 | 400 | 400 |
| 2 | 1.1 | 项目立项（立项申请，立项审批，立项公告） | manual | 1d | 2017-09-01 A | 2017-09-01 A | 100% | 2017-09-01 | 2017-09-01 | 1d | 邓毅伟 | 8h | 8h | 400 | 400 | 400 |
| 3 | 1.2 | 项目启动（项目章程，项目组成立） | manual | 1d | 2017-09-01 A | 2017-09-01 A | 100% | 2017-09-01 | 2017-09-01 | 1d |  |  |  |  |  |  |
| 4 | 2 | **项目策划阶段** |  | 3d | 2017-09-04 A | 2017-09-06 A | 100% | 2017-09-04 | 2017-09-07 | 3d |  | 56h | 56h | 4,000 | 2,400 | 4,000 |
| 5 | 2.1 | 项目过程定义裁剪 | manual | 1d | 2017-09-04 A | 2017-09-04 A | 100% | 2017-09-04 | 2017-09-04 | 1d | 邓毅伟 | 8h | 8h | 400 | 400 | 400 |
| 6 | 2.2 | 构造WBS及项目估算 | manual | 2d | 2017-09-05 A | 2017-09-06 A | 100% | 2017-09-05 | 2017-09-07 | 2d | 邓毅伟 [75%] | 16h | 16h | 800 | 800 | 800 |
| 7 | 2.3 | 项目计划（质量保证计划，配置计划，测试计划，项目测量计划) | manual | 1d | 2017-09-05 A | 2017-09-05 A | 100% | 2017-09-05 | 2017-09-07 | 1d | 蔡杰; 胡威; 屈文敏; 邓毅伟 [25%] | 24h | 24h | 1,200 | 1,200 | 1,200 |
| 8 | 2.4 | 项目计划评审 | manual | 1d | 2017-09-06 A | 2017-09-06 A | 100% |  |  |  | 评审组 | 8h | 8h | 1,600 |  | 1,600 |
| 9 | 3 | **需求阶段** |  | 9d | 2017-09-06 A | 2017-09-18 A | 100% | 2017-09-08 | 2017-09-20 | 9d |  | 104h | 104h | 9,600 | 9,600 | 9,600 |
| 10 | 3.1 | 用户需求说明书 | manual | 4d | 2017-09-06 A | 2017-09-11 A | 100% | 2017-09-08 | 2017-09-14 | 4d | 邓毅伟 | 32h | 32h | 1,600 | 1,600 | 1,600 |
| 11 | 3.2 | 软件需求说明书 | manual | 4d | 2017-09-12 A | 2017-09-15 A | 100% | 2017-09-08 | 2017-09-18 | 4d | 邓毅伟 | 32h | 32h | 1,600 | 1,600 | 1,600 |
| 12 | 3.3 | 需求记录表，功能点及项目计划 | manual | 1d | 2017-09-06 A | 2017-09-06 A | 100% | 2017-09-08 | 2017-09-08 | 1d | 邓毅伟 | 8h | 8h | 400 | 400 | 400 |
| 13 | 3.4 | 用户需求说明书评审会议 | manual | 1d | 2017-09-14 A | 2017-09-14 A | 100% | 2017-09-15 | 2017-09-15 | 1d | 评审组 | 8h | 8h | 1,600 | 1,600 | 1,600 |
| 14 | 3.5 | 软件需求说明书评审 | manual | 1d | 2017-09-18 A | 2017-09-18 A | 100% | 2017-09-19 | 2017-09-19 | 1d | 评审组 | 8h | 8h | 1,600 | 1,600 | 1,600 |
| 15 | 3.6 | 编写需求阶段里程碑报告 | manual | 1d | 2017-09-18 A | 2017-09-18 A | 100% | 2017-09-20 | 2017-09-20 | 1d | 邓毅伟 [70%] | 8h | 8h | 400 | 400 | 400 |
| 16 | 3.7 | 需求阶段里程碑会议 | manual | 1d | 2017-09-18 A | 2017-09-18 A | 100% | 2017-09-20 | 2017-09-20 | 1d | 项目组 | 8h | 8h | 2,400 | 2,400 | 2,400 |
| 17 | 4 | **设计阶段任务** |  | 9d | 2017-09-12 A | 2017-09-22 A | 100% | 2017-09-15 | 2017-09-25 | 9d |  | 168h | 168h | 10,400 | 12,400 | 10,400 |
| 18 | 4.1 | **详细设计** |  | 8d | 2017-09-12 A | 2017-09-21 A | 100% | 2017-09-15 | 2017-09-22 | 8d |  | 144h | 144h | 5,200 | 7,200 | 5,200 |
| 19 | 4.1.1 | 详细设计说明书 | manual | 8d | 2017-09-12 A | 2017-09-21 A | 100% | 2017-09-15 | 2017-09-22 | 8d | 周巨 [80%] | 64h | 64h | 3,200 | 3,200 | 3,200 |
| 20 | 4.1.2 | 数据库设计 | manual | 5d | 2017-09-12 A | 2017-09-18 A | 100% | 2017-09-15 | 2017-09-20 | 5d | 郑康怡; 周巨 | 80h | 80h | 2,000 | 4,000 | 2,000 |
| 21 | 4.2 | 设计阶段详细设计说明书评审会议 | manual | 1d | 2017-09-22 A | 2017-09-22 A | 100% | 2017-09-25 | 2017-09-25 | 1d | 项目组 | 8h | 8h | 2,400 | 2,400 | 2,400 |
| 22 | 4.3 | 设计阶段详细设计里程碑报告编写 | manual | 1d | 2017-09-22 A | 2017-09-22 A | 100% | 2017-09-25 | 2017-09-25 | 1d | 邓毅伟 [70%] | 8h | 8h | 400 | 400 | 400 |
| 23 | 4.4 | 设计阶段详细设计里程碑会议 | manual | 1d | 2017-09-22 A | 2017-09-22 A | 100% | 2017-09-25 | 2017-09-25 | 1d | 项目组 | 8h | 8h | 2,400 | 2,400 | 2,400 |
| 24 | 5 | **编码和单元测试阶段** |  | 24d | 2017-09-15 A | 2017-10-25 A | 100% | 2017-09-15 | 2017-10-27 | 24d |  | 464h | 464h | 25,200 | 27,200 | 25,200 |
| 25 | 5.1 | **编码** |  | 23d | 2017-09-15 A | 2017-10-24 A | 100% | 2017-09-15 | 2017-10-26 | 23d |  | 448h | 448h | 22,400 | 24,400 | 22,400 |
| 26 | 5.1.1 | **业务监控** |  | 6d | 2017-09-15 A | 2017-09-22 A | 100% | 2017-09-15 | 2017-09-22 | 6d |  | 56h | 56h | 2,800 | 2,800 | 2,800 |
| 27 | 5.1.1.1 | 编码 | manual | 4d | 2017-09-15 A | 2017-09-20 A | 100% | 2017-09-15 | 2017-09-20 | 4d | 周巨 | 32h | 32h | 1,600 | 1,600 | 1,600 |
| 28 | 5.1.1.2 | 单元测试 | manual | 1d | 2017-09-21 A | 2017-09-21 A | 100% | 2017-09-21 | 2017-09-21 | 1d | 周巨 | 8h | 8h | 400 | 400 | 400 |
| 29 | 5.1.1.3 | 代码走查 | manual | 1d | 2017-09-21 A | 2017-09-21 A | 100% | 2017-09-21 | 2017-09-21 | 1d | 邓毅伟 | 8h | 8h | 400 | 400 | 400 |
| 30 | 5.1.1.4 | 代码返工 | manual | 1d | 2017-09-22 A | 2017-09-22 A | 100% | 2017-09-22 | 2017-09-22 | 1d | 周巨 | 8h | 8h | 400 | 400 | 400 |

| ID | WBS | Task | Type | Duration | Start | Finish | Complete | Baseline start | Baseline finish | Baseline duration | Constraint | Resources | Work | Actual work | Cost | Baseline cost | Actual cost |
| --- | --- | --- | --- | --- | --- | --- | --- | --- | --- | --- | --- | --- | --- | --- | --- | --- | --- |
| 31 | 5.1.2 | **发票管理** |  | 17d | 2017-09-23 A | 2017-10-24 A | 100% | 2017-09-23 | 2017-10-26 | 17d |  |  | 184h | 184h | 9,200 | 11,200 | 9,200 |
| 32 | 5.1.2.1 | 编码 | manual | 13d | 2017-09-23 A | 2017-10-17 A | 100% | 2017-09-23 | 2017-10-20 | 18d |  | 周巨 | 144h | 144h | 7,200 | 9,200 | 7,200 |
| 33 | 5.1.2.2 | 单元测试 | manual | 1d | 2017-10-18 A | 2017-10-18 A | 100% | 2017-10-20 | 2017-10-20 | 1d |  | 周巨 | 8h | 8h | 400 | 400 | 400 |
| 34 | 5.1.2.3 | 代码走查 | manual | 1d | 2017-10-19 A | 2017-10-19 A | 100% | 2017-10-23 | 2017-10-23 | 1d |  | 邓毅伟 | 8h | 8h | 400 | 400 | 400 |
| 35 | 5.1.2.4 | 代码返工 | manual | 3d | 2017-10-20 A | 2017-10-24 A | 100% | 2017-10-23 | 2017-10-26 | 3d |  | 周巨 | 24h | 24h | 1,200 | 1,200 | 1,200 |
| 36 | 5.1.3 | **授权管理** |  | 12d | 2017-10-09 A | 2017-10-24 A | 100% | 2017-10-09 | 2017-10-25 | 12d |  |  | 112h | 112h | 5,600 | 5,600 | 5,600 |
| 37 | 5.1.3.1 | 编码 | manual | 10d | 2017-10-09 A | 2017-10-20 A | 100% | 2017-10-09 | 2017-10-20 | 10d |  | 郑康怡 | 80h | 80h | 4,000 | 4,000 | 4,000 |
| 38 | 5.1.3.2 | 单元测试 | manual | 1d | 2017-10-21 A | 2017-10-21 A | 100% | 2017-10-21 | 2017-10-21 | 1d |  | 郑康怡 | 8h | 8h | 400 | 400 | 400 |
| 39 | 5.1.3.3 | 代码走查 | manual | 1d | 2017-10-23 A | 2017-10-23 A | 100% | 2017-10-23 | 2017-10-23 | 1d |  | 邓毅伟 | 8h | 8h | 400 | 400 | 400 |
| 40 | 5.1.3.4 | 代码返工 | manual | 2d | 2017-10-23 A | 2017-10-24 A | 100% | 2017-10-23 | 2017-10-25 | 2d |  | 郑康怡 | 16h | 16h | 800 | 800 | 800 |
| 41 | 5.1.4 | **系统管理** |  | 11d | 2017-09-15 A | 2017-09-29 A | 100% | 2017-09-15 | 2017-09-29 | 11d |  |  | 96h | 96h | 4,800 | 4,800 | 4,800 |
| 42 | 5.1.4.1 | 编码 | manual | 7d | 2017-09-15 A | 2017-09-25 A | 100% | 2017-09-15 | 2017-09-25 | 7d |  | 郑康怡 | 56h | 56h | 2,800 | 2,800 | 2,800 |
| 43 | 5.1.4.2 | 单元测试 | manual | 2d | 2017-09-26 A | 2017-09-27 A | 100% | 2017-09-27 | 2017-09-27 | 2d |  | 郑康怡 | 16h | 16h | 800 | 800 | 800 |
| 44 | 5.1.4.3 | 代码走查 | manual | 1d | 2017-09-28 A | 2017-09-28 A | 100% | 2017-09-28 | 2017-09-28 | 1d |  | 邓毅伟 | 8h | 8h | 400 | 400 | 400 |
| 45 | 5.1.4.4 | 代码返工 | manual | 2d | 2017-09-28 A | 2017-09-29 A | 100% | 2017-09-29 | 2017-09-29 | 2d |  | 郑康怡 | 16h | 16h | 800 | 800 | 800 |
| 46 | 5.2 | 编码阶段里程碑报告编写 | manual | 1d | 2017-10-25 A | 2017-10-25 A | 100% | 2017-10-27 | 2017-10-27 | 1d |  | 邓毅伟 [70%] | 8h | 8h | 400 | 400 | 400 |
| 47 | 5.3 | 编码阶段里程碑会议 | manual | 1d | 2017-10-25 A | 2017-10-25 A | 100% | 2017-10-27 | 2017-10-27 | 1d |  | 项目组 | 8h | 8h | 2,400 | 2,400 | 2,400 |
| 48 | 6 | **集成及测试阶段** |  | 25d | 2017-09-25 A | 2017-11-05 A | 100% | 2017-09-25 | 2017-11-06 | 25d |  |  | 272h | 272h | 19,200 | 19,600 | 19,200 |
| 49 | 6.1 | **系统测试** |  | 21d | 2017-09-25 A | 2017-10-30 A | 100% | 2017-09-25 | 2017-10-31 | 21d |  |  | 208h | 208h | 11,600 | 12,000 | 11,600 |
| 50 | 6.1.1 | 测试用例 | manual | 7d | 2017-09-25 A | 2017-10-10 A | 100% | 2017-09-25 | 2017-10-10 | 7d |  | 蔡杰 | 96h | 96h | 4,800 | 4,800 | 4,800 |
| 51 | 6.1.2 | 测试用例评审 | manual | 1d | 2017-10-11 A | 2017-10-11 A | 100% | 2017-10-11 | 2017-10-11 | 1d |  | 评审组 | 8h | 8h | 1,600 | 1,600 | 1,600 |
| 52 | 6.1.3 | 第一轮测试 | manual | 7d | 2017-10-12 A | 2017-10-20 A | 100% | 2017-10-12 | 2017-10-23 | 7d |  | 蔡杰 | 56h | 56h | 2,800 | 2,800 | 2,800 |
| 53 | 6.1.4 | 第二轮测试 | manual | 5d | 2017-10-23 A | 2017-10-27 A | 100% | 2017-10-26 | 2017-10-31 | 6d | start no earlier than 2017-10-23 | 蔡杰 | 40h | 40h | 2,000 | 2,400 | 2,000 |
| 54 | 6.1.5 | 系统测试报告编写 | manual | 1d | 2017-10-30 A | 2017-10-30 A | 100% | 2017-10-31 | 2017-10-31 | 1d |  | 蔡杰 | 8h | 8h | 400 | 400 | 400 |

| ID | WBS | Task | Type | Duration | Start | Finish | Complete | Baseline start | Baseline finish | Baseline duration | Constraint | Resources | Work | Actual work | Cost | Baseline cost | Actual cost |
| --- | --- | --- | --- | --- | --- | --- | --- | --- | --- | --- | --- | --- | --- | --- | --- | --- | --- |
| 55 | 6.2 | **用户手册** |  | 3d | 2017-11-01 A | 2017-11-05 A | 100% | 2017-11-03 | 2017-11-06 | 3d |  |  | 40h | 40h | 3,200 | 3,200 | 3,200 |
| 56 | 6.2.1 | 用户手册编写（用户安装手册，用户操作手册） | manual | 3d | 2017-11-01 A | 2017-11-03 A | 100% | 2017-11-03 | 2017-11-06 | 3d |  | 蔡杰 | 24h | 24h | 1,200 | 1,200 | 1,200 |
| 57 | 6.2.2 | 用户手册评审 | manual | 1d | 2017-11-04 A | 2017-11-04 A | 100% | 2017-11-06 | 2017-11-06 | 1d |  | 评审组 | 8h | 8h | 1,600 | 1,600 | 1,600 |
| 58 | 6.2.3 | 用户手册返工 | manual | 1d | 2017-11-05 A | 2017-11-05 A | 100% | 2017-11-06 | 2017-11-06 | 1d |  | 蔡杰 | 8h | 8h | 400 | 400 | 400 |
| 59 | 6.3 | 测试阶段评审会议 | manual | 1d | 2017-10-31 A | 2017-10-31 A | 100% | 2017-11-01 | 2017-11-01 | 1d |  | 评审组 | 8h | 8h | 1,600 | 1,600 | 1,600 |
| 60 | 6.4 | 编写测试阶段里程碑报告 | manual | 1d | 2017-10-31 A | 2017-10-31 A | 100% | 2017-11-02 | 2017-11-02 | 1d |  | 邓毅伟 [50%] | 8h | 8h | 400 | 400 | 400 |
| 61 | 6.5 | 测试阶段里程碑会议 | manual | 1d | 2017-10-31 A | 2017-10-31 A | 100% | 2017-11-02 | 2017-11-02 | 1d | start no earlier than 2017-10-31 | 项目组 | 8h | 8h | 2,400 | 2,400 | 2,400 |
| 62 | 7 | **试运行** |  | 5d | 2017-11-03 A | 2017-11-09 A | 100% | 2017-11-03 | 2017-11-09 | 5d |  |  | 80h | 80h | 3,600 | 3,600 | 3,600 |
| 63 | 7.1 | **系统安装** |  | 1d | 2017-11-03 A | 2017-11-03 A | 100% | 2017-11-03 | 2017-11-03 | 1d |  |  | 16h | 16h | 800 | 800 | 800 |
| 64 | 7.1.1 | 软件安装 | manual | 1d | 2017-11-03 A | 2017-11-03 A | 100% | 2017-11-03 | 2017-11-03 | 1d |  | 郑康怡 | 8h | 8h | 400 | 400 | 400 |
| 65 | 7.1.2 | 现场培训 | manual | 1d | 2017-11-03 A | 2017-11-03 A | 100% | 2017-11-03 | 2017-11-03 | 1d |  | 蔡杰 | 8h | 8h | 400 | 400 | 400 |
| 66 | 7.2 | 系统试运行 | manual | 5d | 2017-11-03 A | 2017-11-09 A | 100% | 2017-11-03 | 2017-11-09 | 5d |  | 周巨 | 40h | 40h | 2,000 | 2,000 | 2,000 |
| 67 | 7.3 | 试运行问题收集 | manual | 1d | 2017-11-09 A | 2017-11-09 A | 100% | 2017-11-09 | 2017-11-09 | 1d |  | 蔡杰 | 8h | 8h | 400 | 400 | 400 |
| 68 | 7.4 | 试运行问题维护 | milestone, manual | 0d | 2017-11-09 A | 2017-11-09 A | 100% | 2017-11-09 | 2017-11-09 | 0d |  | 周巨 |  |  |  |  |  |
| 69 | 7.5 | 试运行情况汇报 | manual | 1d | 2017-11-09 A | 2017-11-09 A | 100% | 2017-11-09 | 2017-11-09 | 1d |  | 周巨 | 8h | 8h | 400 | 400 | 400 |
| 70 | 7.6 | 试运行报告签署 | manual | 1d | 2017-11-09 A | 2017-11-09 A | 100% | 2017-11-09 | 2017-11-09 | 1d |  | 用户代表 | 8h | 8h |  |  |  |
| 71 | 8 | **项目验收及移交** |  | 5d | 2017-11-03 A | 2017-11-09 A | 100% | 2017-11-03 | 2017-11-13 | 5d |  |  | 112h | 112h | 9,600 | 9,600 | 9,600 |
| 72 | 8.1 | **项目验收** |  | 5d | 2017-11-03 A | 2017-11-09 A | 100% | 2017-11-03 | 2017-11-13 | 5d |  |  | 72h | 72h | 6,000 | 6,000 | 6,000 |
| 73 | 8.1.1 | 验收申请 | manual | 1d | 2017-11-03 A | 2017-11-03 A | 100% | 2017-11-03 | 2017-11-09 | 1d |  | 邓毅伟 [50%] | 8h | 8h | 400 | 400 | 400 |
| 74 | 8.1.2 | 制订验收计划、验收测试计划、验收测试用例编写 | manual | 2d | 2017-11-03 A | 2017-11-06 A | 100% | 2017-11-03 | 2017-11-09 | 2d |  | 邓毅伟 | 16h | 16h | 800 | 800 | 800 |
| 75 | 8.1.3 | 验收准备 | manual | 2d | 2017-11-03 A | 2017-11-06 A | 100% | 2017-11-09 | 2017-11-09 | 2d |  | 项目组 | 16h | 16h | 4,800 | 4,800 | 4,800 |
| 76 | 8.1.4 | 验收测试、系统验收 | manual | 3d | 2017-11-06 A | 2017-11-08 A | 100% | 2017-11-09 | 2017-11-13 | 3d | start no earlier than 2017-11-06 | 用户代表 | 24h | 24h |  |  |  |
| 77 | 8.1.5 | 验收测试报告、验收报告签署 | manual | 1d | 2017-11-09 A | 2017-11-09 A | 100% | 2017-11-13 | 2017-11-13 | 1d | start no earlier than 2017-11-09 | 用户代表 | 8h | 8h |  |  |  |
| 78 | 8.2 | **项目移交** |  | 1d | 2017-11-09 A | 2017-11-09 A | 100% | 2017-11-15 | 2017-11-15 | 1d |  |  | 16h | 16h | 800 | 800 | 800 |
| 79 | 8.2.1 | 确定移交事项 | manual | 1d | 2017-11-09 A | 2017-11-09 A | 100% | 2017-11-15 | 2017-11-15 | 1d |  | 郑康怡 [50%] | 8h | 8h | 400 | 400 | 400 |
| 80 | 8.2.2 | 移交项目技术资料 | manual | 1d | 2017-11-09 A | 2017-11-09 A | 100% | 2017-11-15 | 2017-11-15 | 1d |  | 郑康怡 [50%] | 8h | 8h | 400 | 400 | 400 |
| 81 | 8.3 | 编写验收阶段里程碑报告 | manual | 1d | 2017-11-09 A | 2017-11-09 A | 100% | 2017-11-14 | 2017-11-14 | 1d |  | 邓毅伟 [50%] | 8h | 8h | 400 | 400 | 400 |
| 82 | 8.4 | 验收阶段里程碑会议 | manual | 1d | 2017-11-09 A | 2017-11-09 A | 100% | 2017-11-14 | 2017-11-14 | 1d |  | 项目组; 用户代表 | 16h | 16h | 2,400 | 2,400 | 2,400 |

| ID | WBS | Task | Type | Duration | Start | Finish | Complete | Actual start | Baseline start | Baseline finish | Baseline duration | Constraint | Resources | Work | Actual work | Cost | Baseline cost | Actual cost |
| --- | --- | --- | --- | --- | --- | --- | --- | --- | --- | --- | --- | --- | --- | --- | --- | --- | --- | --- |
| 83 | 9 | **结项** |  | 1d | 2017-11-10 A | 2017-11-10 A | 100% |  | 2017-11-15 | 2017-11-15 | 1d |  |  | 16h | 16h | 2,800 | 2,800 | 2,800 |
| 84 | 9.1 | 项目经理提交项目总结报告 | manual | 1d | 2017-11-10 A | 2017-11-10 A | 100% |  | 2017-11-15 | 2017-11-15 | 1d |  | 邓毅伟 [50%] | 8h | 8h | 400 | 400 | 400 |
| 85 | 9.2 | 召开项目总结会议 | manual | 1d | 2017-11-10 A | 2017-11-10 A | 100% |  | 2017-11-15 | 2017-11-15 | 1d |  | 项目组 | 8h | 8h | 2,400 | 2,400 | 2,400 |
| 86 | 10 | **项目跟踪与监控** |  | 46d | 2017-09-01 A | 2017-11-10 A | 100% |  | 2017-09-01 | 2017-11-15 | 46d |  |  | 104h | 104h | 10,400 | 18,000 | 10,400 |
| 87 | 10.1 | **项目例会** |  | 46d | 2017-09-01 A | 2017-11-10 A | 100% |  | 2017-09-08 | 2017-11-15 | 41d |  |  | 32h | 32h | 7,200 | 16,800 | 7,200 |
| 88 | 10.1.1 | 项目例会 1（风险、度量等） | manual | 1d | 2017-09-01 A | 2017-09-01 A | 100% |  | 2017-09-08 | 2017-09-08 | 1d |  | 项目组 | 8h | 8h |  |  |  |
| 89 | 10.1.2 | 项目例会 2（风险、度量等） | milestone, manual | 0d | 2017-09-15 A | 2017-09-15 A | 100% |  | 2017-09-15 | 2017-09-15 | 0d | start no earlier than 2017-09-15 | 项目组 |  |  |  |  |  |
| 90 | 10.1.3 | 项目例会 3（风险、度量等） | manual | 1d | 2017-10-16 A | 2017-10-16 A | 100% |  | 2017-09-22 | 2017-09-22 | 1d |  | 项目组 | 8h | 8h | 2,400 | 2,400 | 2,400 |
| 91 | 10.1.4 | 项目例会 4（风险、度量等） | manual | 1d | 2017-11-01 A | 2017-11-01 A | 100% |  | 2017-09-29 | 2017-09-29 | 1d |  | 项目组 | 8h | 8h | 2,400 | 2,400 | 2,400 |
| 92 | 10.1.5 | 项目例会 5（风险、度量等） | manual | 1d | 2017-11-10 A | 2017-11-10 A | 100% |  | 2017-10-13 | 2017-10-13 | 1d |  | 项目组 | 8h | 8h | 2,400 | 2,400 | 2,400 |
| 93 | 10.2 | **项目管理、需求分析** |  | 26d | 2017-09-15 A | 2017-10-27 A | 100% |  | 2017-09-15 | 2017-10-27 | 26d |  |  | 32h | 32h | 1,200 | 1,200 | 1,200 |
| 94 | 10.2.1 | 需求、项目管理一 | manual | 1d | 2017-09-15 A | 2017-09-15 A | 100% |  | 2017-09-15 | 2017-09-15 | 1d |  | 邓毅伟 | 8h | 8h |  |  |  |
| 95 | 10.2.2 | 需求、项目管理二 | manual | 1d | 2017-09-29 A | 2017-09-29 A | 100% |  | 2017-09-29 | 2017-09-29 | 1d |  | 邓毅伟 | 8h | 8h | 400 | 400 | 400 |
| 96 | 10.2.3 | 需求、项目管理三 | manual | 1d | 2017-10-13 A | 2017-10-13 A | 100% |  | 2017-10-13 | 2017-10-13 | 1d |  | 邓毅伟 | 8h | 8h | 400 | 400 | 400 |
| 97 | 10.2.4 | 需求、项目管理四 | manual | 1d | 2017-10-27 A | 2017-10-27 A | 100% |  | 2017-10-27 | 2017-10-27 | 1d |  | 邓毅伟 | 8h | 8h | 400 | 400 | 400 |
| 98 | 10.3 | QA工作 | manual | 46d | 2017-09-01 A | 2017-11-10 A | 100% |  | 2017-09-01 | 2017-11-15 | 46d |  |  |  |  |  |  |  |
| 99 | 10.4 | **CM工作** |  | 46d | 2017-09-01 | 2017-11-10 A | 100% | 2017-09-18 | 2017-09-01 | 2017-11-15 | 46d |  |  | 40h | 40h | 2,000 |  | 2,000 |
| 100 | 10.4.1 | **配置报告** |  | 35d | 2017-09-18 A | 2017-11-10 A | 100% |  | 2017-09-20 | 2017-12-15 |  |  |  | 40h | 40h | 2,000 |  | 2,000 |
| 101 | 10.4.1.1 | 需求阶段CM活动报告和基线管理 | manual | 1d | 2017-09-18 A | 2017-09-18 A | 100% |  | 2017-09-21 | 2017-09-21 |  |  | 胡威 | 8h | 8h | 400 |  | 400 |
| 102 | 10.4.1.2 | 设计阶段CM活动报告和基线管理 | manual | 1d | 2017-09-22 A | 2017-09-22 A | 100% |  | 2017-09-26 | 2017-09-26 | 0d |  | 胡威 | 8h | 8h | 400 |  | 400 |
| 103 | 10.4.1.3 | 实现阶段CM活动报告和基线管理 | manual | 1d | 2017-10-25 A | 2017-10-25 A | 100% |  | 2017-10-30 | 2017-10-30 |  |  | 胡威 | 8h | 8h | 400 |  | 400 |
| 104 | 10.4.1.4 | 测试阶段CM活动报告和基线管理 | manual | 1d | 2017-10-31 A | 2017-10-31 A | 100% |  | 2017-11-03 | 2017-11-03 |  |  | 胡威 | 8h | 8h | 400 |  | 400 |
| 105 | 10.4.1.5 | 验收阶段CM活动报告和基线管理 | manual | 1d | 2017-11-10 A | 2017-11-10 A | 100% |  | 2017-11-15 | 2017-12-15 |  |  | 胡威 | 8h | 8h | 400 |  | 400 |
